# ITP 3 Week 4 Rev2

Schedule from MS Project, 2017-06-07 to 2017-08-15, costs in $.

## Calendars

- Standard: Mon-Fri 08:00-12:00, 13:00-17:00; Sat-Sun off.

## Resources

| Resource | Rate | Cost per use |
| --- | --- | --- |
| Cristy Conner - Project Sponsor | 115.3 | 3689.6 |
| Edward Guzinski - Project Manager | 115.3 | 4150.8 |
| Antonio Jones - Requirements | 115.3 | 20477.3 |
| Yvelisse Orana - Business Analyst | 115.3 | 5534.4 |
| Tremaine Shivers - Technical Architect | 115.3 | 25827.2 |
| Victor Wynn - Quality Assurance/Test Engineer | 115.3 | 14573.9 |
| 12 Network Cables | 20 | 240 |
| 1 24 port network switch | 2000 | 2000 |
| 1 Firewall | 1200 | 1200 |
| 1 Storage and Active Directory Server | 1000 | 1000 |
| 10 PCs | 10000 | 10000 |
| 10 Tablets | 5000 | 5000 |
| 1 X-ray Machine | 14710 | 14710 |
| ScheduleOne Appointment Software | 6000 | 6000 |
| Curve Dental Hero | 6000 | 6000 |
| Norton Anti-Virus | 6000 | 6000 |
| Microsoft PowerPoint | 2000 | 2000 |
| Training Video |  |  |
| External Backup Server | 5000 | 5000 |
| Network Contractors | 80 | 5760 |
| WiFi Extender | 600 | 600 |
| Dental Employees | 277.8 | 10000 |
| Internet Modem | 250 |  |

## Schedule

| ID | WBS | Task | Duration | Start | Finish | Predecessors | Total slack | Free slack | Constraint | Resources | Work | Cost |
| --- | --- | --- | --- | --- | --- | --- | --- | --- | --- | --- | --- | --- |
| 1 | 1 | **Set Up IT System for Marley's Dental Clinic** | 50d | 2017-06-07 08:00 | 2017-08-15 17:00 |  | 0d |  |  |  | 680h | 2,627,668.64 |
| 2 | 1.1 | **Finalize Project Plan** | 2d | 2017-06-07 08:00 | 2017-06-08 17:00 |  | 45d |  |  |  | 24h | 34,774.48 |
| 3 | 1.1.1 | **Project team and client meeting** | 2d | 2017-06-07 08:00 | 2017-06-08 17:00 |  | 45d |  |  |  | 24h | 34,774.48 |
| 4 | 1.1.1.1 | Review project plan | 1d | 2017-06-07 08:00 | 2017-06-07 17:00 |  | 45d | 0d |  | Cristy Conner - Project Sponsor; Edward Guzinski - Project Manager | 16h | 9,685.2 |
| 5 | 1.1.1.2 | Review budget | 0.5d | 2017-06-08 08:00 | 2017-06-08 12:00 | 4 | 45d | 0d |  | Cristy Conner - Project Sponsor | 4h | 4,150.8 |
| 6 | 1.1.1.3 | Finalize requirements | 0.5d | 2017-06-08 13:00 | 2017-06-08 17:00 | 5 | 45d | 0d |  | Antonio Jones - Requirements | 4h | 20,938.48 |
| 7 | 1.2 | **Order Hardware** | 15d | 2017-06-09 08:00 | 2017-06-29 17:00 |  | 0d |  |  |  | 224h | 463,044.8 |
| 8 | 1.2.1 | **Order computers** | 3d | 2017-06-09 08:00 | 2017-06-13 17:00 |  |  |  |  |  | 48h | 98,143.36 |
| 9 | 1.2.1.1 | Determine type of computers needed | 2d | 2017-06-09 08:00 | 2017-06-12 17:00 | 6 | 45d | 0d | start no earlier than 2017-06-09 08:00 | Tremaine Shivers - Technical Architect; Antonio Jones - Requirements | 32h | 49,994.08 |
| 10 | 1.2.1.2 | Determine quantity of computers needed | 1d | 2017-06-13 08:00 | 2017-06-13 17:00 | 9 | 45d |  |  | Tremaine Shivers - Technical Architect; Antonio Jones - Requirements | 16h | 48,149.28 |
| 11 | 1.2.2 | **Order tablets** | 3d | 2017-06-14 08:00 | 2017-06-16 17:00 |  |  |  |  |  | 48h | 98,143.36 |
| 12 | 1.2.2.1 | Determine type of tablets needed | 2d | 2017-06-14 08:00 | 2017-06-15 17:00 | 6 | 42d | 0d | start no earlier than 2017-06-14 08:00 | Tremaine Shivers - Technical Architect; Antonio Jones - Requirements | 32h | 49,994.08 |
| 13 | 1.2.2.2 | Determine number of tablets needed | 1d | 2017-06-16 08:00 | 2017-06-16 17:00 | 12 | 42d |  |  | Tremaine Shivers - Technical Architect; Antonio Jones - Requirements | 16h | 48,149.28 |
| 14 | 1.2.3 | **Order server** | 3d | 2017-06-19 08:00 | 2017-06-21 17:00 |  |  |  |  |  | 48h | 98,143.36 |
| 15 | 1.2.3.1 | Determine type of server needed | 2d | 2017-06-19 08:00 | 2017-06-20 17:00 | 6 | 39d | 0d | start no earlier than 2017-06-19 08:00 | Tremaine Shivers - Technical Architect; Antonio Jones - Requirements | 32h | 49,994.08 |
| 16 | 1.2.3.2 | Determine number of servers needed | 1d | 2017-06-21 08:00 | 2017-06-21 17:00 | 15 | 39d |  | start no earlier than 2017-06-21 08:00 | Tremaine Shivers - Technical Architect; Antonio Jones - Requirements | 16h | 48,149.28 |
| 17 | 1.2.4 | **Order network cables** | 3d | 2017-06-22 08:00 | 2017-06-26 17:00 |  |  |  |  |  | 32h | 70,471.36 |
| 18 | 1.2.4.1 | Determine length and quantity needed | 2d | 2017-06-22 08:00 | 2017-06-23 17:00 | 6 | 36d | 0d | start no earlier than 2017-06-22 08:00 | Antonio Jones - Requirements | 16h | 22,322.08 |
| 19 | 1.2.4.2 | Determine number of plenum cables needed | 1d | 2017-06-26 08:00 | 2017-06-26 17:00 | 18 | 36d |  |  | Tremaine Shivers - Technical Architect; Antonio Jones - Requirements | 16h | 48,149.28 |
| 20 | 1.2.5 | **Order network switch** | 3d | 2017-06-27 08:00 | 2017-06-29 17:00 |  |  |  |  |  | 48h | 98,143.36 |
| 21 | 1.2.5.1 | Determine type of switches needed | 2d | 2017-06-27 08:00 | 2017-06-28 17:00 | 6 | 33d | 0d | finish no earlier than 2017-06-28 17:00 | Tremaine Shivers - Technical Architect; Antonio Jones - Requirements | 32h | 49,994.08 |
| 22 | 1.2.5.2 | Determine number of switches needed | 1d | 2017-06-29 08:00 | 2017-06-29 17:00 | 21 | 33d |  | finish no earlier than 2017-06-29 17:00 | Tremaine Shivers - Technical Architect; Antonio Jones - Requirements | 16h | 48,149.28 |
| 23 | 1.3 | **Order Software** | 1d | 2017-06-30 08:00 | 2017-06-30 17:00 |  |  |  |  |  | 16h | 338,758.24 |
| 24 | 1.3.1 | Buy appointment software | 0.3d | 2017-06-30 08:00 | 2017-06-30 10:24 | 6 | 32.7d |  |  | Tremaine Shivers - Technical Architect; Antonio Jones - Requirements; ScheduleOne Appointment Software [1000%] | 4.8h | 112,857.92 |
| 25 | 1.3.2 | Buy Curve Dental Hero | 0.3d | 2017-06-30 08:00 | 2017-06-30 10:24 | 6 | 32.7d |  |  | Tremaine Shivers - Technical Architect; Antonio Jones - Requirements; Curve Dental Hero [1000%] | 4.8h | 112,857.92 |
| 26 | 1.3.3 | Register for anti-virus software | 0.4d | 2017-06-30 08:00 | 2017-06-30 11:12 | 6 | 32.6d |  |  | Tremaine Shivers - Technical Architect; Antonio Jones - Requirements; Norton Anti-Virus [1000%] | 6.4h | 113,042.4 |

| ID | WBS | Task | Duration | Start | Finish | Predecessors | Total slack | Free slack | Constraint | Resources | Work | Cost |
| --- | --- | --- | --- | --- | --- | --- | --- | --- | --- | --- | --- | --- |
| 27 | 1.4 | **Network Installation** | 14d | 2017-07-03 08:00 | 2017-07-20 17:00 |  |  |  |  |  | 108h | 185,212.32 |
| 28 | 1.4.1 | **Find networking contractors** | 6d | 2017-07-03 08:00 | 2017-07-10 17:00 |  | 23d |  |  |  | 60h | 120,062 |
| 29 | 1.4.1.1 | Research networking contractors | 2d | 2017-07-03 08:00 | 2017-07-04 17:00 |  | 23d | 0d |  | Yvelisse Orana - Business Analyst | 16h | 7,379.2 |
| 30 | 1.4.1.2 | **Contact networking contractor** | 4d | 2017-07-05 08:00 | 2017-07-10 17:00 |  | 23d |  |  |  | 44h | 112,682.8 |
| 31 | 1.4.1.2.1 | Negotiate contract | 2d | 2017-07-05 08:00 | 2017-07-06 17:00 | 29 | 23d | 0d | start no earlier than 2017-06-07 08:00 | Yvelisse Orana - Business Analyst; Network Contractors | 16h | 13,219.2 |
| 32 | 1.4.1.2.2 | Sign contract | 0.5d | 2017-07-07 08:00 | 2017-07-07 12:00 | 31 | 23d | 0d |  | Cristy Conner - Project Sponsor | 4h | 4,150.8 |
| 33 | 1.4.1.2.3 | Schedule networking install | 0.5d | 2017-07-07 13:00 | 2017-07-07 17:00 | 32 | 23d | 0d |  | Antonio Jones - Requirements; Tremaine Shivers - Technical Architect | 8h | 47,226.88 |
| 34 | 1.4.1.2.4 | Install network gear | 1d | 2017-07-10 08:00 | 2017-07-10 17:00 | 33 | 23d | 0d |  | Tremaine Shivers - Technical Architect; Victor Wynn - Quality Assurance/Test Engineer; Network Contractors | 16h | 48,085.92 |
| 35 | 1.4.2 | **Contact ISP** | 3d | 2017-07-11 08:00 | 2017-07-13 17:00 |  |  |  |  |  | 24h | 11,991.2 |
| 36 | 1.4.2.1 | Negotiate contract | 2d | 2017-07-11 08:00 | 2017-07-12 17:00 | 34 | 23d | 0d |  | Yvelisse Orana - Business Analyst | 16h | 7,379.2 |
| 37 | 1.4.2.2 | Sign contract | 1d | 2017-07-13 08:00 | 2017-07-13 17:00 | 36 | 23d |  |  | Cristy Conner - Project Sponsor | 8h | 4,612 |
| 38 | 1.4.3 | **ISP Install** | 2d | 2017-07-17 08:00 | 2017-07-18 17:00 |  |  |  |  |  | 24h | 53,159.12 |
| 39 | 1.4.3.1 | Schedule install | 1d | 2017-07-17 08:00 | 2017-07-17 17:00 |  | 15.8d | 0d | start no earlier than 2017-07-17 08:00 | Edward Guzinski - Project Manager | 8h | 5,073.2 |
| 40 | 1.4.3.2 | Conduct install | 1d | 2017-07-18 08:00 | 2017-07-18 17:00 | 39 | 15.8d | 2d |  | Tremaine Shivers - Technical Architect; Victor Wynn - Quality Assurance/Test Engineer; Network Contractors | 16h | 48,085.92 |
| 41 | 1.5 | **Implement Technology** | 5d | 2017-07-21 08:00 | 2017-07-27 17:00 |  |  |  |  |  | 48h | 485,990.48 |
| 42 | 1.5.1 | **Set Up PCs** | 3d | 2017-07-21 08:00 | 2017-07-25 17:00 |  |  |  |  |  | 32h | 280,276.88 |
| 43 | 1.5.1.1 | Connect PCs to wireless network | 2d | 2017-07-21 08:00 | 2017-07-24 17:00 | 40 | 15.7d | 0d |  | Victor Wynn - Quality Assurance/Test Engineer; 10 PCs; WiFi Extender; Internet Modem; Network Contractors | 16h | 43,708.72 |
| 44 | 1.5.1.2 | Install appointment software | 0.3d | 2017-07-25 08:00 | 2017-07-25 10:24 | 43 | 15.7d |  |  | Tremaine Shivers - Technical Architect; Victor Wynn - Quality Assurance/Test Engineer; 10 PCs; ScheduleOne Appointment Software; Network Contractors | 4.8h | 78,794.56 |
| 45 | 1.5.1.3 | Install Curve Dental Hero | 0.3d | 2017-07-25 08:00 | 2017-07-25 10:24 |  | 15.7d |  | start no earlier than 2017-07-25 08:00 | Tremaine Shivers - Technical Architect; Victor Wynn - Quality Assurance/Test Engineer; 10 PCs; Curve Dental Hero; Network Contractors | 4.8h | 78,794.56 |
| 46 | 1.5.1.4 | Install anti-virus software | 0.4d | 2017-07-25 08:00 | 2017-07-25 11:12 |  | 15.6d |  | start no earlier than 2017-07-25 08:00 | Tremaine Shivers - Technical Architect; Victor Wynn - Quality Assurance/Test Engineer; 10 PCs; Norton Anti-Virus; Network Contractors | 6.4h | 78,979.04 |
| 47 | 1.5.2 | **Set up Tablets** | 2d | 2017-07-26 08:00 | 2017-07-27 17:00 |  |  |  |  |  | 16h | 205,713.6 |
| 48 | 1.5.2.1 | Connect tablets to wireless network | 1d | 2017-07-26 08:00 | 2017-07-26 17:00 | 40 | 10.8d | 0d |  | Tremaine Shivers - Technical Architect; 10 Tablets; WiFi Extender; Network Contractors | 8h | 43,789.6 |
| 49 | 1.5.2.2 | Install appointment software | 0.4d | 2017-07-27 08:00 | 2017-07-27 11:12 | 48 | 10.8d | 0.6d |  | Tremaine Shivers - Technical Architect; 10 Tablets; ScheduleOne Appointment Software; Network Contractors | 3.2h | 54,036.16 |
| 50 | 1.5.2.3 | Install curve Dental Hero | 0.3d | 2017-07-27 08:00 | 2017-07-27 10:24 | 48 | 10.8d | 0.7d |  | Tremaine Shivers - Technical Architect; 10 Tablets; Curve Dental Hero; Network Contractors | 2.4h | 53,943.92 |
| 51 | 1.5.2.4 | Install anti-virus software | 0.3d | 2017-07-27 08:00 | 2017-07-27 10:24 | 48 | 13.7d |  | start no earlier than 2017-07-24 08:00 | Tremaine Shivers - Technical Architect; 10 Tablets; Norton Anti-Virus; Network Contractors | 2.4h | 53,943.92 |

| ID | WBS | Task | Duration | Start | Finish | Predecessors | Total slack | Free slack | Constraint | Resources | Work | Cost |
| --- | --- | --- | --- | --- | --- | --- | --- | --- | --- | --- | --- | --- |
| 52 | 1.6 | **Test Technology** | 1d | 2017-07-28 08:00 | 2017-07-28 17:00 |  |  |  |  |  | 8h | 170,644.16 |
| 53 | 1.6.1 | Add a client into appointment software | 0.3d | 2017-07-28 08:00 | 2017-07-28 10:24 | 49 | 10.2d |  |  | Victor Wynn - Quality Assurance/Test Engineer; 10 PCs; 10 Tablets; ScheduleOne Appointment Software | 2.4h | 56,850.64 |
| 54 | 1.6.2 | Verify that you can find the newly added appointment | 0.3d | 2017-07-28 08:00 | 2017-07-28 10:24 |  | 12.7d |  | start no earlier than 2017-07-28 08:00 | Victor Wynn - Quality Assurance/Test Engineer; 10 PCs; 10 Tablets; ScheduleOne Appointment Software | 2.4h | 56,850.64 |
| 55 | 1.6.3 | Evaluate Curve Dental Hero by locating insurance information | 0.4d | 2017-07-28 08:00 | 2017-07-28 11:12 | 50 | 10.1d |  |  | Victor Wynn - Quality Assurance/Test Engineer; 10 PCs; 10 Tablets; Curve Dental Hero | 3.2h | 56,942.88 |
| 56 | 1.7 | **Train Employees** | 10d | 2017-07-31 08:00 | 2017-08-11 17:00 |  |  |  |  |  | 156h | 567,826.16 |
| 57 | 1.7.1 | Build training material | 2d | 2017-07-31 08:00 | 2017-08-01 17:00 | 52 | 9.5d | 0d |  | Tremaine Shivers - Technical Architect; Victor Wynn - Quality Assurance/Test Engineer; Antonio Jones - Requirements; 10 PCs; Microsoft PowerPoint | 48h | 90,412.8 |
| 58 | 1.7.2 | Set up training environment | 0.5d | 2017-08-02 08:00 | 2017-08-02 12:00 | 57 | 9.5d |  |  | Tremaine Shivers - Technical Architect; Victor Wynn - Quality Assurance/Test Engineer; Antonio Jones - Requirements; 10 PCs | 12h | 82,262 |
| 59 | 1.7.3 | Schedule training | 0.5d | 2017-08-02 08:00 | 2017-08-02 12:00 |  | 7d | 0.5d | start no earlier than 2017-08-02 08:00 | Edward Guzinski - Project Manager; Dental Employees | 8h | 15,723.2 |
| 60 | 1.7.4 | **Conduct Training** | 4d | 2017-08-03 08:00 | 2017-08-08 17:00 |  |  |  |  |  | 88h | 379,428.16 |
| 61 | 1.7.4.1 | Run employees through training videos on appointment software | 1d | 2017-08-03 08:00 | 2017-08-03 17:00 | 59 | 6.5d | 0d |  | Antonio Jones - Requirements; 10 PCs; Dental Employees; Microsoft PowerPoint; Training Video | 16h | 57,622.08 |
| 62 | 1.7.4.2 | Let employees test drive appointment software | 1d | 2017-08-04 08:00 | 2017-08-04 17:00 | 61 | 6.5d | 1.5d |  | Tremaine Shivers - Technical Architect; Victor Wynn - Quality Assurance/Test Engineer; 10 PCs; ScheduleOne Appointment Software; Dental Employees | 24h | 86,468.32 |
| 63 | 1.7.4.3 | Run employees through training videos on Curve Dental Hero | 1d | 2017-08-07 08:00 | 2017-08-07 17:00 |  | 5d | 0d | start no earlier than 2017-08-07 08:00 | Tremaine Shivers - Technical Architect; Victor Wynn - Quality Assurance/Test Engineer; 10 PCs; Dental Employees; Training Video | 24h | 74,468.32 |
| 64 | 1.7.4.4 | Let employees test drive Curve Dental Hero | 0.5d | 2017-08-08 08:00 | 2017-08-08 12:00 | 63 | 5d | 0d |  | Tremaine Shivers - Technical Architect; Victor Wynn - Quality Assurance/Test Engineer; 10 PCs; Curve Dental Hero; Dental Employees | 12h | 84,434.72 |
| 65 | 1.7.4.5 | Regroup for questions on both softwares | 0.5d | 2017-08-08 13:00 | 2017-08-08 17:00 | 62, 64 | 5d |  | start no earlier than 2017-07-13 08:00 | Tremaine Shivers - Technical Architect; Victor Wynn - Quality Assurance/Test Engineer; Dental Employees; ScheduleOne Appointment Software; Curve Dental Hero | 12h | 76,434.72 |
| 66 | 1.8 | **Guage How Team is Feeling** | 2d | 2017-08-09 08:00 | 2017-08-10 17:00 |  |  |  |  |  | 56h | 93,900.32 |
| 67 | 1.8.1 | Gather team for meeting to assess changes | 1d | 2017-08-09 08:00 | 2017-08-09 17:00 |  | 3d | 0d |  | Edward Guzinski - Project Manager; Victor Wynn - Quality Assurance/Test Engineer; Tremaine Shivers - Technical Architect; Cristy Conner - Project Sponsor; Antonio Jones - Requirements | 40h | 73,330.8 |
| 68 | 1.8.2 | Talk individually to team for feedback | 1d | 2017-08-10 08:00 | 2017-08-10 17:00 | 67 | 3d |  |  | Edward Guzinski - Project Manager; Victor Wynn - Quality Assurance/Test Engineer | 16h | 20,569.52 |
| 69 | 1.9 | **Maintenance on IT System** | 3d | 2017-08-11 08:00 | 2017-08-15 17:00 |  |  |  |  |  | 40h | 287,517.68 |
| 70 | 1.9.1 | Run system check on internet | 0.3d | 2017-08-11 08:00 | 2017-08-11 10:24 |  | 2.7d |  | start no earlier than 2017-08-11 08:00 | Victor Wynn - Quality Assurance/Test Engineer; 10 PCs; Internet Modem | 2.4h | 35,100.64 |
| 71 | 1.9.2 | Back up financial data and customer records | 0.7d | 2017-08-11 08:00 | 2017-08-11 14:36 |  | 2.3d |  | start no earlier than 2017-08-11 08:00 | Antonio Jones - Requirements; External Backup Server; 1 Storage and Active Directory Server | 5.6h | 33,122.96 |
| 72 | 1.9.3 | Run updates for PCs | 0.5d | 2017-08-14 08:00 | 2017-08-14 12:00 |  | 1.5d |  | start no earlier than 2017-08-14 08:00 | Victor Wynn - Quality Assurance/Test Engineer; Tremaine Shivers - Technical Architect; 10 PCs | 8h | 61,323.52 |
| 73 | 1.9.4 | Run updates for tablets | 0.5d | 2017-08-14 08:00 | 2017-08-14 12:00 |  | 1.5d |  | start no earlier than 2017-08-14 08:00 | Victor Wynn - Quality Assurance/Test Engineer; Tremaine Shivers - Technical Architect; 10 Tablets | 8h | 51,323.52 |
| 74 | 1.9.5 | Update appointment software to latest version | 0.5d | 2017-08-15 08:00 | 2017-08-15 12:00 |  | 0.5d |  | start no earlier than 2017-08-15 08:00 | Victor Wynn - Quality Assurance/Test Engineer; Tremaine Shivers - Technical Architect; ScheduleOne Appointment Software | 8h | 53,323.52 |
| 75 | 1.9.6 | Update Curve Dental Hero to latest version | 0.5d | 2017-08-15 08:00 | 2017-08-15 12:00 |  | 0.5d |  | start no earlier than 2017-08-15 08:00 | Victor Wynn - Quality Assurance/Test Engineer; Tremaine Shivers - Technical Architect; Curve Dental Hero | 8h | 53,323.52 |
